# Productieschema ontwerpproces complexe utiliteitsbouw

Schedule from MS Project, 2002-12-30 to 2003-08-29.
BAM Nelissen Van Egteren

## Calendars

- Standaard: Mon-Fri 08:30-12:30, 13:00-17:00; Sat-Sun off.

## Schedule

| ID | WBS | Task | Type | Duration | Start | Finish | Predecessors | Total slack | Free slack |
| --- | --- | --- | --- | --- | --- | --- | --- | --- | --- |
| 1 | 1 | **INITIATIEF** |  | 40d | 2002-12-30 | 2003-02-21 |  | 135d |  |
| 2 | 1.1 | discussie over huisvestingsproblemen |  | 4w | 2002-12-30 | 2003-01-24 |  | 135d | 0d |
| 3 | 1.2 | klachten over bestaande huisvesting |  | 2w | 2003-01-27 | 2003-02-07 | 2 | 135d | 0d |
| 4 | 1.3 | voordelen van nieuwe huisvesting |  | 2w | 2003-02-10 | 2003-02-21 | 3 | 135d | 0d |
| 5 | 1.4 | besluit: haalbaarheid onderzoeken | milestone | 0w | 2003-02-21 | 2003-02-21 | 4 | 135d |  |
| 7 | 2 | **HAALBAARHEID** |  | 80d | 2002-12-30 | 2003-04-18 |  | 95d |  |
| 8 | 2.1 | **organiseren** |  | 15d | 2002-12-30 | 2003-01-17 |  | 95d |  |
| 9 | 2.1.1 | plan van aanpak maken |  | 2w | 2002-12-30 | 2003-01-10 |  | 95d | 0d |
| 10 | 2.1.2 | programma-team bemannen |  | 1w | 2003-01-13 | 2003-01-17 | 9 | 95d | 0d |
| 11 | 2.2 | **programmeren: functioneel** |  | 25d | 2003-01-20 | 2003-02-21 |  | 95d |  |
| 12 | 2.2.1 | concept functionele analyse |  | 2w | 2003-01-20 | 2003-01-31 | 10 | 95d | 0d |
| 13 | 2.2.2 | overleg met betrokkenen |  | 1w | 2003-02-03 | 2003-02-07 | 12 | 135d | 0d |
| 14 | 2.2.3 | document functionele analyse |  | 2w | 2003-02-10 | 2003-02-21 | 13 | 135d |  |
| 15 | 2.3 | **programmeren: ruimtelijk** |  | 25d | 2003-02-03 | 2003-03-07 |  | 115d |  |
| 16 | 2.3.1 | concept ruimtelijke analyse |  | 2w | 2003-02-03 | 2003-02-14 | 12 | 115d | 0d |
| 17 | 2.3.2 | overleg met betrokkenen |  | 1w | 2003-02-17 | 2003-02-21 | 16 | 115d | 0d |
| 18 | 2.3.3 | document ruimtelijke analyse |  | 2w | 2003-02-24 | 2003-03-07 | 17 | 115d | 0d |
| 19 | 2.4 | **programmeren: technisch** |  | 25d | 2003-02-03 | 2003-03-07 |  | 95d |  |
| 20 | 2.4.1 | concept technische analyse |  | 2w | 2003-02-03 | 2003-02-14 | 12 | 95d | 0d |
| 21 | 2.4.2 | overleg met betrokkenen |  | 1w | 2003-02-17 | 2003-02-21 | 20 | 115d | 0d |
| 22 | 2.4.3 | document technische analyse |  | 2w | 2003-02-24 | 2003-03-07 | 21 | 115d | 0d |
| 23 | 2.5 | **programmeren: financieel** |  | 25d | 2003-02-17 | 2003-03-21 |  | 95d |  |
| 24 | 2.5.1 | concept financiele analyse |  | 2w | 2003-02-17 | 2003-02-28 | 20 | 95d | 0d |
| 25 | 2.5.2 | overleg met betrokkene |  | 1w | 2003-03-03 | 2003-03-07 | 24 | 95d | 0d |
| 26 | 2.5.3 | document financiele analyse |  | 2w | 2003-03-10 | 2003-03-21 | 25 | 95d | 0d |

| ID | WBS | Task | Type | Duration | Start | Finish | Predecessors | Total slack | Free slack |
| --- | --- | --- | --- | --- | --- | --- | --- | --- | --- |
| 27 | 2.6 | **beoordelen** |  | 20d | 2003-03-10 | 2003-04-04 |  | 105d |  |
| 28 | 2.6.1 | toets ruimtelijk aan functioneel |  | 2w | 2003-03-10 | 2003-03-21 | 18 | 115d |  |
| 29 | 2.6.2 | toets technisch aan functioneel |  | 2w | 2003-03-10 | 2003-03-21 | 22 | 115d |  |
| 30 | 2.6.3 | toets financieel aan functioneel |  | 2w | 2003-03-24 | 2003-04-04 | 26 | 95d | 0d |
| 31 | 2.7 | **besluiten** |  | 10d | 2003-04-07 | 2003-04-18 |  | 95d |  |
| 32 | 2.7.1 | besluitvorming voorbereiden |  | 2w | 2003-04-07 | 2003-04-18 | 30 | 95d | 0d |
| 33 | 2.7.2 | haalbaarheid goedgekeurd | milestone | 0w | 2003-04-18 | 2003-04-18 | 32 | 95d |  |
| 35 | 3 | **PROJECTDEFINITIE** |  | 105d | 2002-12-30 | 2003-05-23 |  | 70d |  |
| 36 | 3.1 | **organiseren** |  | 10d | 2002-12-30 | 2003-01-10 |  | 165d |  |
| 37 | 3.1.1 | plan van aanpak opstellen |  | 2w | 2002-12-30 | 2003-01-10 |  | 165d |  |
| 38 | 3.1.2 | programmateam bemannen |  | 1w | 2002-12-30 | 2003-01-03 |  | 170d |  |
| 39 | 3.2 | **programmeren: functioneel** |  | 35d | 2002-12-30 | 2003-02-14 |  | 70d |  |
| 40 | 3.2.1 | concept funct. basisprogramma |  | 3w | 2002-12-30 | 2003-01-17 |  | 70d | 0d |
| 41 | 3.2.2 | overleg met betrokkenen |  | 2w | 2003-01-20 | 2003-01-31 | 40 | 140d | 0d |
| 42 | 3.2.3 | document funct. basisprogramma |  | 2w | 2003-02-03 | 2003-02-14 | 41 | 140d |  |
| 43 | 3.3 | **programmeren: ruimtelijk** |  | 35d | 2003-01-20 | 2003-03-07 |  | 70d |  |
| 44 | 3.3.1 | concept ruimtelijk basisprogramma |  | 3w | 2003-01-20 | 2003-02-07 | 40 | 70d | 0d |
| 45 | 3.3.2 | overleg met betrokkene |  | 2w | 2003-02-10 | 2003-02-21 | 44 | 115d | 0d |
| 46 | 3.3.3 | document ruimtelijk basisprogramma |  | 2w | 2003-02-24 | 2003-03-07 | 45 | 115d | 0d |
| 47 | 3.4 | **programmeren: technisch** |  | 35d | 2003-02-10 | 2003-03-28 |  | 70d |  |
| 48 | 3.4.1 | concept technisch basisprogramma |  | 3w | 2003-02-10 | 2003-02-28 | 44 | 70d | 0d |
| 49 | 3.4.2 | overleg met betrokkenen |  | 2w | 2003-03-03 | 2003-03-14 | 48 | 100d | 0d |
| 50 | 3.4.3 | document technisch basisprogram |  | 2w | 2003-03-17 | 2003-03-28 | 49 | 100d | 0d |
| 51 | 3.5 | **programmeren: financieel** |  | 35d | 2003-03-03 | 2003-04-18 |  | 70d |  |
| 52 | 3.5.1 | concept financieel basisprogramma |  | 3w | 2003-03-03 | 2003-03-21 | 48 | 70d | 0d |
| 53 | 3.5.2 | overleg met betrokkenen |  | 2w | 2003-03-24 | 2003-04-04 | 52 | 70d | 0d |
| 54 | 3.5.3 | document financieel basisprogramma |  | 2w | 2003-04-07 | 2003-04-18 | 53 | 70d | 0d |

| ID | WBS | Task | Type | Duration | Start | Finish | Predecessors | Total slack | Free slack |
| --- | --- | --- | --- | --- | --- | --- | --- | --- | --- |
| 55 | 3.6 | **beoordelen** |  | 40d | 2003-03-10 | 2003-05-02 |  | 85d |  |
| 56 | 3.6.1 | toets ruimtelijk program aan funct. |  | 2w | 2003-03-10 | 2003-03-21 | 46 | 115d |  |
| 57 | 3.6.2 | toets technisch program aan funct. |  | 2w | 2003-03-31 | 2003-04-11 | 50 | 100d |  |
| 58 | 3.6.3 | toets financieel program aan funct. |  | 2w | 2003-04-21 | 2003-05-02 | 54 | 70d | 0d |
| 59 | 3.7 | **besluiten** |  | 15d | 2003-05-05 | 2003-05-23 |  | 70d |  |
| 60 | 3.7.1 | besluitvorming voorbereiden |  | 3w | 2003-05-05 | 2003-05-23 | 58 | 70d | 0d |
| 61 | 3.7.2 | projectdefinitie goedgekeurd | milestone | 0w | 2003-05-23 | 2003-05-23 | 60 | 70d |  |
| 63 | 4 | **STRUCTUUR ONTWERP** |  | 160d | 2002-12-30 | 2003-08-08 |  | 15d |  |
| 64 | 4.1 | opdracht voor structuur ontwerp | milestone | 0w | 2002-12-30 | 2002-12-30 |  | 15d | 0d |
| 65 | 4.2 | **organiseren: plan van aanpak** |  | 30d | 2002-12-30 | 2003-02-07 |  | 145d |  |
| 66 | 4.2.1 | plan van aanpak opstellen |  | 2w | 2002-12-30 | 2003-01-10 | 64 | 145d | 0d |
| 67 | 4.2.2 | overleg over plan van aanpak |  | 2w | 2003-01-13 | 2003-01-24 | 66 | 145d | 0d |
| 68 | 4.2.3 | document plan van aanpak |  | 1w | 2003-01-27 | 2003-01-31 | 67 | 145d | 0d |
| 69 | 4.2.4 | project-organisatie bemannen |  | 1w | 2003-02-03 | 2003-02-07 | 68 | 145d |  |
| 70 | 4.3 | **organiseren: architect** |  | 30d | 2002-12-30 | 2003-02-07 |  | 15d |  |
| 71 | 4.3.1 | selecteren architect |  | 2w | 2002-12-30 | 2003-01-10 | 64 | 15d | 0d |
| 72 | 4.3.2 | overleg met architect over program |  | 2w | 2003-01-13 | 2003-01-24 | 71 | 15d | 0d |
| 73 | 4.3.3 | opstellen ontwerpopdracht |  | 2w | 2003-01-27 | 2003-02-07 | 72 | 15d | 0d |
| 74 | 4.3.4 | tekenen ontwerpopdracht | milestone | 0w | 2003-02-07 | 2003-02-07 | 73 | 15d | 0d |
| 75 | 4.4 | **programmeren** |  | 20d | 2002-12-30 | 2003-01-24 |  | 155d |  |
| 76 | 4.4.1 | funct. basisprogram actualiseren |  | 2w | 2002-12-30 | 2003-01-10 | 64 | 155d | 0d |
| 77 | 4.4.2 | ruimtelijk basisprogram actualiseren |  | 2w | 2003-01-06 | 2003-01-17 | 76SS+1w | 155d | 0d |
| 78 | 4.4.3 | technisch basisprogram actualiseren |  | 1w | 2003-01-13 | 2003-01-17 | 77SS+1w | 155d | 0d |
| 79 | 4.4.4 | financieel basisprogram actualiseren |  | 1w | 2003-01-20 | 2003-01-24 | 78SS+1w | 155d |  |

| ID | WBS | Task | Type | Duration | Start | Finish | Predecessors | Total slack | Free slack |
| --- | --- | --- | --- | --- | --- | --- | --- | --- | --- |
| 80 | 4.5 | **ontwerpen: structuur ontwerp** |  | 70d | 2003-02-10 | 2003-05-16 |  | 15d |  |
| 81 | 4.5.1 | nota ontwerp - uitgangspunten |  | 2w | 2003-02-10 | 2003-02-21 | 74 | 15d | 0d |
| 82 | 4.5.2 | structuur ontwerp variant 1 |  | 4w | 2003-02-24 | 2003-03-21 | 81 | 15d | 0d |
| 83 | 4.5.3 | structuur ontwerp variant 2 |  | 3w | 2003-03-17 | 2003-04-04 | 82SS+3w | 105d |  |
| 84 | 4.5.4 | structuur ontwerp variant 3 |  | 3w | 2003-03-31 | 2003-04-18 | 82SS+5w | 15d | 0d |
| 85 | 4.5.5 | overleg over ontwerp varianten |  | 3w | 2003-04-21 | 2003-05-09 | 84 | 15d | 0d |
| 86 | 4.5.6 | kiezen van ontwerp-variant |  | 1w | 2003-05-12 | 2003-05-16 | 85 | 15d | 0d |
| 87 | 4.6 | **begroten** |  | 30d | 2003-05-19 | 2003-06-27 |  | 15d |  |
| 88 | 4.6.1 | element-cluster begroting concept |  | 3w | 2003-05-19 | 2003-06-06 | 86 | 15d | 0d |
| 89 | 4.6.2 | overleg over begroting |  | 2w | 2003-06-09 | 2003-06-20 | 88 | 15d | 0d |
| 90 | 4.6.3 | element-cluster begroting afronden |  | 1w | 2003-06-23 | 2003-06-27 | 89 | 15d | 0d |
| 91 | 4.7 | **beoordelen** |  | 50d | 2003-05-19 | 2003-07-25 |  | 25d |  |
| 92 | 4.7.1 | toets SO aan functioneel programma |  | 2w | 2003-05-19 | 2003-05-30 | 86 | 45d | 0d |
| 93 | 4.7.2 | toets SO aan ruimtelijk programma |  | 2w | 2003-06-02 | 2003-06-13 | 92 | 45d | 0d |
| 94 | 4.7.3 | toets SO aan technisch programma |  | 2w | 2003-06-16 | 2003-06-27 | 93 | 45d |  |
| 95 | 4.7.4 | toets SO aan financieel programma |  | 2w | 2003-06-30 | 2003-07-11 | 90 | 15d | 0d |
| 96 | 4.7.5 | afwijkingsrapport opstellen |  | 2w | 2003-07-14 | 2003-07-25 | 95 | 15d | 0d |
| 97 | 4.8 | **besluiten** |  | 10d | 2003-07-28 | 2003-08-08 |  | 15d |  |
| 98 | 4.8.1 | besluitvorming voorbereiden |  | 2w | 2003-07-28 | 2003-08-08 | 96 | 15d | 0d |
| 99 | 4.8.2 | structuurontwerp goedgekeurd | milestone | 0w | 2003-08-08 | 2003-08-08 | 98 | 15d |  |
| 101 | 5 | **VOORLOPIG ONTWERP** |  | 175d | 2002-12-30 | 2003-08-29 |  | 0d |  |
| 102 | 5.1 | opdracht voor voorlopig ontwerp | milestone | 0w | 2002-12-30 | 2002-12-30 |  | 0d |  |
| 103 | 5.2 | **organiseren: plan van aanpak** |  | 40d | 2002-12-30 | 2003-02-21 |  | 0d |  |
| 104 | 5.2.1 | plan van aanpak opstellen |  | 2w | 2002-12-30 | 2003-01-10 | 102 | 0d |  |
| 105 | 5.2.2 | overleg over plan van aanpak |  | 2w | 2003-01-13 | 2003-01-24 | 104 | 0d |  |
| 106 | 5.2.3 | document plan van aanpak |  | 2w | 2003-01-27 | 2003-02-07 | 105 | 0d |  |
| 107 | 5.2.4 | project-team bemannen |  | 2w | 2003-02-10 | 2003-02-21 | 106 | 0d |  |

| ID | WBS | Task | Type | Duration | Start | Finish | Predecessors | Total slack | Free slack |
| --- | --- | --- | --- | --- | --- | --- | --- | --- | --- |
| 108 | 5.3 | **organiseren: adviseurs aantrekken** |  | 20d | 2002-12-30 | 2003-01-24 |  | 155d |  |
| 109 | 5.3.1 | selecteren constructiebureau |  | 2w | 2002-12-30 | 2003-01-10 | 102 | 155d | 0d |
| 110 | 5.3.2 | ontwerp-contract opstellen |  | 2w | 2003-01-13 | 2003-01-24 | 109 | 155d | 0d |
| 111 | 5.3.3 | tekenen contract constructiebureau | milestone | 0w | 2003-01-24 | 2003-01-24 | 110 | 155d |  |
| 112 | 5.3.4 | selecteren installatie-bureau |  | 2w | 2002-12-30 | 2003-01-10 | 102 | 155d | 0d |
| 113 | 5.3.5 | ontwerp-contract opstellen |  | 2w | 2003-01-13 | 2003-01-24 | 112 | 155d | 0d |
| 114 | 5.3.6 | tekenen contract installatie-bureau | milestone | 0w | 2003-01-24 | 2003-01-24 | 113 | 155d |  |
| 115 | 5.4 | **ontwerpen: bouwkundig** |  | 90d | 2003-02-24 | 2003-06-27 |  | 0d |  |
| 116 | 5.4.1 | concept indelingsplannen |  | 10w | 2003-02-24 | 2003-05-02 | 107 | 0d |  |
| 117 | 5.4.2 | overleg indeling met gebruikers |  | 10w | 2003-03-24 | 2003-05-30 | 116SS+4w | 35d | 0d |
| 118 | 5.4.3 | document indelingsplannen maken |  | 10w | 2003-04-21 | 2003-06-27 | 117SS+4w | 35d | 0d |
| 119 | 5.4.4 | concept gevel aanzichten |  | 4w | 2003-02-24 | 2003-03-21 | 116SS | 85d | 0d |
| 120 | 5.4.5 | overleg over gevels |  | 2w | 2003-03-24 | 2003-04-04 | 119 | 85d | 0d |
| 121 | 5.4.6 | document gevelaanzichten maken |  | 4w | 2003-04-07 | 2003-05-02 | 120 | 85d |  |
| 122 | 5.5 | **ontwerpen: draagconstructie** |  | 50d | 2003-03-24 | 2003-05-30 |  | 65d |  |
| 123 | 5.5.1 | concept ontwerp draagconstructie |  | 4w | 2003-03-24 | 2003-04-18 | 116SS+4w | 65d | 0d |
| 124 | 5.5.2 | overleg over draagconstructie |  | 3w | 2003-04-21 | 2003-05-09 | 123 | 65d | 0d |
| 125 | 5.5.3 | document draagconstructie maken |  | 3w | 2003-05-12 | 2003-05-30 | 124 | 65d |  |
| 126 | 5.6 | **ontwerpen: installatie** |  | 55d | 2003-03-24 | 2003-06-06 |  | 0d |  |
| 127 | 5.6.1 | concept ontwerp installatie |  | 4w | 2003-03-24 | 2003-04-18 | 116SS+4w | 0d |  |
| 128 | 5.6.2 | overleg over installaties |  | 3w | 2003-04-21 | 2003-05-09 | 127 | 0d |  |
| 129 | 5.6.3 | document ontwerp installaties |  | 4w | 2003-05-12 | 2003-06-06 | 128 | 0d |  |
| 130 | 5.7 | **begroten** |  | 30d | 2003-06-09 | 2003-07-18 |  | 0d |  |
| 131 | 5.7.1 | elementenbegroting maken |  | 2w | 2003-06-09 | 2003-06-20 | 129 | 0d |  |
| 132 | 5.7.2 | overleg over elementen begroting |  | 2w | 2003-06-23 | 2003-07-04 | 131 | 0d |  |
| 133 | 5.7.3 | document elementen-begroting |  | 2w | 2003-07-07 | 2003-07-18 | 132 | 0d |  |

| ID | WBS | Task | Type | Duration | Start | Finish | Predecessors | Total slack | Free slack |
| --- | --- | --- | --- | --- | --- | --- | --- | --- | --- |
| 134 | 5.8 | **beoordelen** |  | 60d | 2003-05-26 | 2003-08-15 |  | 10d |  |
| 135 | 5.8.1 | toets VO aan functioneel programma |  | 2w | 2003-05-26 | 2003-06-06 | 118FF-3w | 60d |  |
| 136 | 5.8.2 | toets VO aan ruimtelijk programma |  | 2w | 2003-06-30 | 2003-07-11 | 118 | 35d |  |
| 137 | 5.8.3 | toets VO aan technisch programma |  | 2w | 2003-06-09 | 2003-06-20 | 129 | 50d |  |
| 138 | 5.8.4 | toets VO aan financieel programma |  | 2w | 2003-07-21 | 2003-08-01 | 133 | 0d |  |
| 139 | 5.8.5 | afwijkingsrapport maken |  | 2w | 2003-08-04 | 2003-08-15 | 138 | 0d |  |
| 140 | 5.9 | **besluiten** |  | 10d | 2003-08-18 | 2003-08-29 |  | 0d |  |
| 141 | 5.9.1 | besluitvorming voorbereiden |  | 2w | 2003-08-18 | 2003-08-29 | 139 | 0d |  |
| 142 | 5.9.2 | voorlopig ontwerp goedgekeurd | milestone | 0w | 2003-08-29 | 2003-08-29 | 141 | 0d |  |
| 144 | 6 | **DEFINITIEF ONTWERP** |  | 175d | 2002-12-30 | 2003-08-29 |  | 0d |  |
| 145 | 6.1 | opdracht voor definitief ontwerp | milestone | 0w | 2002-12-30 | 2002-12-30 |  | 0d |  |
| 146 | 6.2 | **organiseren** |  | 40d | 2002-12-30 | 2003-02-21 |  | 0d |  |
| 147 | 6.2.1 | plan van aanpak uitwerken |  | 2w | 2002-12-30 | 2003-01-10 | 145 | 0d |  |
| 148 | 6.2.2 | overleg over plan van aanpak |  | 2w | 2003-01-13 | 2003-01-24 | 147 | 0d |  |
| 149 | 6.2.3 | document plan van aanpak maken |  | 2w | 2003-01-27 | 2003-02-07 | 148 | 0d |  |
| 150 | 6.2.4 | projectteam bemannen |  | 2w | 2003-02-10 | 2003-02-21 | 149 | 135d |  |
| 151 | 6.3 | **programmeren** |  | 25d | 2002-12-30 | 2003-01-31 |  | 150d |  |
| 152 | 6.3.1 | actualiseren funct. basisprogram |  | 1w | 2002-12-30 | 2003-01-03 | 145 | 150d | 0d |
| 153 | 6.3.2 | actualiseren ruimtelijk basisprogram |  | 2w | 2003-01-06 | 2003-01-17 | 152 | 150d | 0d |
| 154 | 6.3.3 | actualiseren technisch basisprogram |  | 1w | 2003-01-20 | 2003-01-24 | 153 | 150d | 0d |
| 155 | 6.3.4 | actualiseren financieel basisprogram |  | 1w | 2003-01-27 | 2003-01-31 | 154 | 150d |  |
| 156 | 6.4 | **ontwerpen: bouwkundig** |  | 90d | 2003-02-10 | 2003-06-13 |  | 0d |  |
| 157 | 6.4.1 | plattegronden tekening uitwerken |  | 10w | 2003-02-10 | 2003-04-18 | 149 | 0d |  |
| 158 | 6.4.2 | overleg met gebruikers |  | 10w | 2003-03-10 | 2003-05-16 | 157SS+4w | 45d | 0d |
| 159 | 6.4.3 | document plattegronden maken |  | 10w | 2003-04-07 | 2003-06-13 | 158SS+4w | 45d | 0d |
| 160 | 6.4.4 | ontwerp gevels + daken uitwerken |  | 4w | 2003-03-10 | 2003-04-04 | 157SS+4w | 55d | 0d |
| 161 | 6.4.5 | overleg over gevels + daken |  | 4w | 2003-04-07 | 2003-05-02 | 160 | 55d | 0d |
| 162 | 6.4.6 | document ontwerp gevels + daken |  | 4w | 2003-05-05 | 2003-05-30 | 161 | 55d | 0d |

| ID | WBS | Task | Type | Duration | Start | Finish | Predecessors | Total slack | Free slack |
| --- | --- | --- | --- | --- | --- | --- | --- | --- | --- |
| 163 | 6.5 | **ontwerpen: draagconstructie** |  | 60d | 2003-03-10 | 2003-05-30 |  | 65d |  |
| 164 | 6.5.1 | draagconstructie verder uitwerken |  | 4w | 2003-03-10 | 2003-04-04 | 157SS+4w | 65d | 0d |
| 165 | 6.5.2 | overleg over draagconstructie |  | 4w | 2003-04-07 | 2003-05-02 | 164 | 65d | 0d |
| 166 | 6.5.3 | document ontwerp draagconstructie |  | 4w | 2003-05-05 | 2003-05-30 | 165 | 65d |  |
| 167 | 6.6 | **ontwerpen: installaties** |  | 60d | 2003-03-10 | 2003-05-30 |  | 0d |  |
| 168 | 6.6.1 | ontwerp installatie verder uitwerken |  | 4w | 2003-03-10 | 2003-04-04 | 157SS+4w | 0d |  |
| 169 | 6.6.2 | overleg over installaties |  | 4w | 2003-04-07 | 2003-05-02 | 168 | 0d |  |
| 170 | 6.6.3 | document ontwerp installaties maken |  | 4w | 2003-05-05 | 2003-05-30 | 169 | 0d |  |
| 171 | 6.7 | **begroten** |  | 30d | 2003-06-02 | 2003-07-11 |  | 0d |  |
| 172 | 6.7.1 | elementenmateriaal begroting concept |  | 2w | 2003-06-02 | 2003-06-13 | 170 | 0d |  |
| 173 | 6.7.2 | overleg over begroting |  | 2w | 2003-06-16 | 2003-06-27 | 172 | 0d |  |
| 174 | 6.7.3 | document elementen-begroting maken |  | 2w | 2003-06-30 | 2003-07-11 | 173 | 0d |  |
| 175 | 6.8 | **beoordelen** |  | 50d | 2003-06-02 | 2003-08-08 |  | 15d |  |
| 176 | 6.8.1 | toets DO aan functioneel basisprogram |  | 2w | 2003-06-02 | 2003-06-13 | 162 | 55d |  |
| 177 | 6.8.2 | toets DO aan ruimtelijk basisprogram |  | 2w | 2003-06-16 | 2003-06-27 | 159 | 45d |  |
| 178 | 6.8.3 | toets DO aan technisch basisprogram |  | 2w | 2003-06-02 | 2003-06-13 | 170 | 55d |  |
| 179 | 6.8.4 | toets DO aan financieel basisprogram |  | 2w | 2003-07-14 | 2003-07-25 | 174 | 0d |  |
| 180 | 6.8.5 | afwijkingsrapport maken |  | 2w | 2003-07-28 | 2003-08-08 | 179 | 0d |  |
| 181 | 6.9 | **besluiten** |  | 15d | 2003-08-11 | 2003-08-29 |  | 0d |  |
| 182 | 6.9.1 | besluitvorming voorbereiden |  | 3w | 2003-08-11 | 2003-08-29 | 180 | 0d |  |
| 183 | 6.9.2 | goedkeuring definitief ontwerp | milestone | 0w | 2003-08-29 | 2003-08-29 | 182 | 0d |  |
| 185 | 7 | **BESTEK & TEKENING** |  | 160d | 2002-12-30 | 2003-08-08 |  | 15d |  |
| 186 | 7.1 | opdracht start bestek & tekening | milestone | 0w | 2002-12-30 | 2002-12-30 |  | 15d | 0d |
| 187 | 7.2 | **organiseren** |  | 40d | 2002-12-30 | 2003-02-21 |  | 15d |  |
| 188 | 7.2.1 | plan van aanpak concept uitwerken |  | 2w | 2002-12-30 | 2003-01-10 | 186 | 15d | 0d |
| 189 | 7.2.2 | overleg over plan van aanpak |  | 2w | 2003-01-13 | 2003-01-24 | 188 | 15d | 0d |
| 190 | 7.2.3 | document plan van aanpak |  | 2w | 2003-01-27 | 2003-02-07 | 189 | 15d | 0d |
| 191 | 7.2.4 | project-team bemannen |  | 2w | 2003-02-10 | 2003-02-21 | 190 | 15d | 0d |

| ID | WBS | Task | Duration | Start | Finish | Predecessors | Total slack | Free slack |
| --- | --- | --- | --- | --- | --- | --- | --- | --- |
| 192 | 7.3 | **ontwerpen: bouwkundig bestek** | 85d | 2003-02-24 | 2003-06-20 |  | 15d |  |
| 193 | 7.3.1 | plattegrond tekeningen maken | 11w | 2003-02-24 | 2003-05-09 | 191 | 15d | 0d |
| 194 | 7.3.2 | gevels en daken tekeningen maken | 7w | 2003-03-24 | 2003-05-09 | 193SS+4w | 80d |  |
| 195 | 7.3.3 | doorsnedes+detail tekeningen maken | 7w | 2003-03-24 | 2003-05-09 | 193SS+4w | 80d |  |
| 196 | 7.3.4 | bouwkundig bestek schrijven | 7w | 2003-03-24 | 2003-05-09 | 193SS+4w | 80d |  |
| 197 | 7.3.5 | controleren bouwkundig bestek&tek | 4w | 2003-05-12 | 2003-06-06 | 193 | 15d | 0d |
| 198 | 7.3.6 | document bouwkundig bestek&tek | 2w | 2003-06-09 | 2003-06-20 | 197 | 15d | 0d |
| 199 | 7.4 | **ontwerpen: constructie bestek** | 65d | 2003-03-24 | 2003-06-20 |  | 50d |  |
| 200 | 7.4.1 | constructie plattegronden tekenen | 4w | 2003-03-24 | 2003-04-18 | 193SS+4w | 50d | 0d |
| 201 | 7.4.2 | constructie doorsneden+details maken | 3w | 2003-04-21 | 2003-05-09 | 200 | 80d |  |
| 202 | 7.4.3 | constructie bestek schrijven | 4w | 2003-04-14 | 2003-05-09 | 200SS+3w | 50d | 0d |
| 203 | 7.4.4 | controleren constructie bestek&tek | 3w | 2003-05-12 | 2003-05-30 | 202 | 50d | 0d |
| 204 | 7.4.5 | document constructie bestek&tek | 3w | 2003-06-02 | 2003-06-20 | 203 | 50d |  |
| 205 | 7.5 | **ontwerpen: werktuigk. bestek** | 60d | 2003-03-24 | 2003-06-13 |  | 55d |  |
| 206 | 7.5.1 | werktuigkundig bestektek maken | 6w | 2003-03-24 | 2003-05-02 | 193SS+4w | 55d | 0d |
| 207 | 7.5.2 | werktuigkundig bestek schrijven | 4w | 2003-04-07 | 2003-05-02 | 206SS+2w | 55d | 0d |
| 208 | 7.5.3 | controleren werktuigk. bestek&tek | 2w | 2003-05-05 | 2003-05-16 | 207 | 55d | 0d |
| 209 | 7.5.4 | document werktuigk. bestek&tek | 4w | 2003-05-19 | 2003-06-13 | 208 | 55d |  |
| 210 | 7.6 | **ontwerpen: electra bestek** | 65d | 2003-03-24 | 2003-06-20 |  | 50d |  |
| 211 | 7.6.1 | electra bestektek maken | 6w | 2003-03-24 | 2003-05-02 | 193SS+4w | 50d | 0d |
| 212 | 7.6.2 | electra bestek schrijven | 4w | 2003-04-14 | 2003-05-09 | 211SS+3w | 50d | 0d |
| 213 | 7.6.3 | controleren electra. bestek&tek | 2w | 2003-05-12 | 2003-05-23 | 212 | 50d | 0d |
| 214 | 7.6.4 | document electra. bestek&tek | 4w | 2003-05-26 | 2003-06-20 | 213 | 50d |  |
| 215 | 7.7 | **beoordelen** | 20d | 2003-06-23 | 2003-07-18 |  | 15d |  |
| 216 | 7.7.1 | toets bestek aan funct. program | 1w | 2003-06-23 | 2003-06-27 | 198 | 15d | 0d |
| 217 | 7.7.2 | toets bestek aan ruimtelijk program | 1w | 2003-06-30 | 2003-07-04 | 216 | 40d |  |
| 218 | 7.7.3 | toets bestek aan techn. program | 1w | 2003-06-30 | 2003-07-04 | 216 | 15d | 0d |
| 219 | 7.7.4 | toets bestek aan financieel program | 1w | 2003-07-07 | 2003-07-11 | 218 | 15d | 0d |
| 220 | 7.7.5 | afwijkingsrapport maken | 1w | 2003-07-14 | 2003-07-18 | 219 | 15d | 0d |

| ID | WBS | Task | Type | Duration | Start | Finish | Predecessors | Total slack | Free slack |
| --- | --- | --- | --- | --- | --- | --- | --- | --- | --- |
| 221 | 7.8 | **besluiten** |  | 15d | 2003-07-21 | 2003-08-08 |  | 15d |  |
| 222 | 7.8.1 | besluitvorming voorbereiden |  | 3w | 2003-07-21 | 2003-08-08 | 220 | 15d | 0d |
| 223 | 7.8.2 | goedkeuring bestek&tekening | milestone | 0w | 2003-08-08 | 2003-08-08 | 222 | 15d |  |
| 225 | 8 | **PRIJSVORMING** |  | 170d | 2002-12-30 | 2003-08-22 |  | 5d |  |
| 226 | 8.1 | opdracht voor aanbesteding | milestone | 0w | 2002-12-30 | 2002-12-30 |  | 5d | 0d |
| 227 | 8.2 | **organiseren: plan van aanpak** |  | 35d | 2002-12-30 | 2003-02-14 |  | 140d |  |
| 228 | 8.2.1 | plan van aanpak opstellen |  | 2w | 2002-12-30 | 2003-01-10 | 226 | 140d | 0d |
| 229 | 8.2.2 | overleg over plan van aanpak |  | 1w | 2003-01-13 | 2003-01-17 | 228 | 140d | 0d |
| 230 | 8.2.3 | document plan van aanpak |  | 2w | 2003-01-20 | 2003-01-31 | 229 | 140d | 0d |
| 231 | 8.2.4 | project-team bemannen |  | 2w | 2003-02-03 | 2003-02-14 | 230 | 140d |  |
| 232 | 8.3 | **organiseren: uitnodiging aanbest.** |  | 75d | 2002-12-30 | 2003-04-11 |  | 5d |  |
| 233 | 8.3.1 | selectie criteria formuleren |  | 2w | 2002-12-30 | 2003-01-10 | 226 | 5d | 0d |
| 234 | 8.3.2 | gunnings criteria formuleren |  | 2w | 2002-12-30 | 2003-01-10 | 233SS | 5d | 0d |
| 235 | 8.3.3 | bekendmaking aanbesteding |  | 1w | 2003-01-13 | 2003-01-17 | 234 | 5d | 0d |
| 236 | 8.3.4 | aanmeldingstermijn 37 dg |  | 8w | 2003-01-20 | 2003-03-14 | 235 | 5d | 0d |
| 237 | 8.3.5 | beoordelen op selectie-criteria |  | 1w | 2003-03-17 | 2003-03-21 | 236 | 5d | 0d |
| 238 | 8.3.6 | mededeling teveel en 5 loten |  | 1w | 2003-03-24 | 2003-03-28 | 237 | 5d | 0d |
| 239 | 8.3.7 | bestekstukken copieren |  | 1w | 2003-03-31 | 2003-04-04 | 238 | 5d | 0d |
| 240 | 8.3.8 | uitnodiging met bestek-documenten |  | 1w | 2003-04-07 | 2003-04-11 | 239 | 5d | 0d |
| 241 | 8.4 | **begroten: prijsvorming** |  | 40d | 2003-04-14 | 2003-06-06 |  | 5d |  |
| 242 | 8.4.1 | inschrijfbegroting maken 40 dg |  | 8w | 2003-04-14 | 2003-06-06 | 240 | 5d | 0d |
| 243 | 8.4.2 | nadere inlichtingen verstrekken |  | 1w | 2003-05-12 | 2003-05-16 | 242SS+4w | 70d | 0d |
| 244 | 8.4.3 | nota van inlichting verzenden |  | 1w | 2003-05-19 | 2003-05-23 | 243 | 70d |  |
| 245 | 8.5 | **begroten: aanbesteden** |  | 10d | 2003-06-06 | 2003-06-20 |  | 5d |  |
| 246 | 8.5.1 | aanbesteding houden | milestone | 0w | 2003-06-06 | 2003-06-06 | 242 | 5d | 0d |
| 247 | 8.5.2 | aanbieding laagste prijs kiezen |  | 1w | 2003-06-09 | 2003-06-13 | 246 | 5d | 0d |
| 248 | 8.5.3 | begroting laagste inschrijver |  | 1w | 2003-06-16 | 2003-06-20 | 247 | 5d | 0d |

| ID | WBS | Task | Type | Duration | Start | Finish | Predecessors | Total slack | Free slack |
| --- | --- | --- | --- | --- | --- | --- | --- | --- | --- |
| 249 | 8.6 | **beoordelen:** |  | 25d | 2003-06-23 | 2003-07-25 |  | 5d | 0d |
| 250 | 8.6.1 | toets inschrijving aan bouwbudget |  | 2w | 2003-06-23 | 2003-07-04 | 248 | 5d | 0d |
| 251 | 8.6.2 | prijsoverleg met laagste inschrijver |  | 2w | 2003-07-07 | 2003-07-18 | 250 | 5d | 0d |
| 252 | 8.6.3 | afwijkingsrapport maken |  | 1w | 2003-07-21 | 2003-07-25 | 251 | 5d | 0d |
| 253 | 8.7 | **besluiten** |  | 20d | 2003-07-28 | 2003-08-22 | 249 | 5d |  |
| 254 | 8.7.1 | aannemingsovereenkomst opstellen |  | 2w | 2003-07-28 | 2003-08-08 | 252 | 5d | 0d |
| 255 | 8.7.2 | overleg met laagste inschrijver |  | 2w | 2003-08-11 | 2003-08-22 | 254 | 5d | 0d |
| 256 | 8.7.3 | aannemingsovereenkomst tekenen | milestone | 0w | 2003-08-22 | 2003-08-22 | 255 | 5d |  |
| 258 | 9 | **WERKVOORBEREIDING** |  | 45d | 2002-12-30 | 2003-02-28 |  | 130d |  |
| 259 | 9.1 | bouwopdracht+ start werkvoorbereiding | milestone | 0w | 2002-12-30 | 2002-12-30 |  | 130d | 0d |
| 260 | 9.2 | **organiseren** |  | 45d | 2002-12-30 | 2003-02-28 |  | 130d |  |
| 261 | 9.2.1 | productieschema ruwbouw maken |  | 1w | 2002-12-30 | 2003-01-03 | 259 | 130d | 0d |
| 262 | 9.2.2 | procedure contract grondwerk |  | 4w | 2002-12-30 | 2003-01-24 | 259 | 155d |  |
| 263 | 9.2.3 | procedure contract bemaling |  | 4w | 2002-12-30 | 2003-01-24 | 259 | 155d |  |
| 264 | 9.2.4 | procedure contract heiwerk |  | 4w | 2002-12-30 | 2003-01-24 | 259 | 155d |  |
| 265 | 9.2.5 | procedure levering heipalen |  | 6w | 2002-12-30 | 2003-02-07 |  | 145d |  |
| 266 | 9.2.6 | procedure overige onderaannemers |  | 8w | 2003-01-06 | 2003-02-28 | 261 | 130d |  |
| 267 | 9.2.7 | procedure overige leveringen |  | 8w | 2003-01-06 | 2003-02-28 | 261 | 130d |  |
| 268 | 9.3 | **werktekeningen** |  | 20d | 2003-01-06 | 2003-01-31 |  | 150d |  |
| 269 | 9.3.1 | werktekening bouwplaats-inrichting |  | 4w | 2003-01-06 | 2003-01-31 | 261 | 150d |  |
| 270 | 9.3.2 | werktekening palenplan |  | 4w | 2003-01-06 | 2003-01-31 | 261 | 150d |  |
| 271 | 9.3.3 | werktekening betonfundatie |  | 4w | 2003-01-06 | 2003-01-31 | 261 | 150d |  |
| 272 | 9.3.4 | werktekening begane grondvloer |  | 4w | 2003-01-06 | 2003-01-31 | 261 | 150d |  |
| 274 | 10 | **UITVOERING PROJECT** |  | 100d | 2002-12-30 | 2003-05-16 |  | 75d |  |
| 275 | 10.1 | start uitvoering op de bouwplaats | milestone | 0w | 2002-12-30 | 2002-12-30 |  | 95d | 0d |
| 276 | 10.2 | intervaltijd aanloopfase |  | 6w | 2002-12-30 | 2003-02-07 | 275 | 95d | 0d |
| 277 | 10.3 | intervaltijd onderbouwfase |  | 6w | 2003-02-10 | 2003-03-21 | 276 | 95d | 0d |
| 278 | 10.4 | intervaltijd bovenbouwfase |  | 4w | 2003-03-24 | 2003-04-18 | 277 | 95d |  |
| 279 | 10.5 | productietijd bovenbouw |  | 20w | 2002-12-30 | 2003-05-16 |  | 75d |  |
| 280 | 10.6 | intervaltijd gevel/dakfase |  | 10w | 2002-12-30 | 2003-03-07 |  | 85d | 0d |
| 281 | 10.7 | intervaltijd afbouwfase |  | 8w | 2003-03-10 | 2003-05-02 | 280 | 85d |  |
| 282 | 10.8 | productietijd afbouw |  | 20w | 2002-12-30 | 2003-05-16 |  | 75d |  |

| ID | WBS | Task | Type | Duration | Start | Finish | Predecessors | Total slack | Free slack |
| --- | --- | --- | --- | --- | --- | --- | --- | --- | --- |
| 284 | 11 | **OPLEVERING GEBOUW** |  | 60d | 2002-12-30 | 2003-03-21 |  | 115d |  |
| 285 | 11.1 | vooropname en gebreken registreren |  | 3w | 2002-12-30 | 2003-01-17 |  | 115d | 0d |
| 286 | 11.2 | gebreken vooraf herstellen |  | 3w | 2003-01-20 | 2003-02-07 | 285 | 115d | 0d |
| 287 | 11.3 | formele oplevering | milestone | 0w | 2003-02-07 | 2003-02-07 | 286 | 115d | 0d |
| 288 | 11.4 | gebreken herstellen |  | 6w | 2003-02-10 | 2003-03-21 | 287 | 115d |  |
| 289 | 11.5 | inrichten door opdrachtgever |  | 6w | 2003-02-10 | 2003-03-21 | 287SS | 115d | 0d |
| 290 | 11.6 | overhuizen naar nieuwe huisvesting | milestone | 0w | 2003-03-21 | 2003-03-21 | 289 | 115d |  |
